# ProjectPlanCALICE

Schedule from MS Project, 2006-04-03 to 2009-04-30, status date 2006-04-19.
CLRC

## Calendars

- Standard: Mon-Fri 08:00-12:00, 13:00-17:00; Sat-Sun off.

## Resources

| Resource |
| --- |
| JC |
| IC? |
| RAL |
| RAL Technology |
| Silicon Foundry |
| Imperial College |

## Schedule

| ID | WBS | Task | Type | Duration | Start | Finish | Predecessors | Total slack | Constraint | Resources | Work |
| --- | --- | --- | --- | --- | --- | --- | --- | --- | --- | --- | --- |
| 1 | 1 | **Feasability Study** |  | 24d | 2006-04-03 | 2006-05-04 |  | 0d |  | RAL Technology | 384h |
| 2 | 1.1 | Complete Feasability Study |  | 1mo | 2006-04-03 | 2006-04-28 |  | 0d |  | JC | 160h |
| 3 | 1.2 | Prepare Specification Docs |  | 4d | 2006-05-01 | 2006-05-04 | 2 | 0d |  | JC | 32h |
| 4 | 2 | ASIC1 Preliminary Design Review | milestone | 1d | 2006-05-05 | 2006-05-05 | 3 | 0d | start no earlier than 2006-05-05 |  |  |
| 5 | 3 | ASIC1 Design Period (Initial schedule) |  | 8mo | 2006-05-08 | 2006-12-15 | 4 | 619d |  |  |  |
| 6 | 4 | **ASIC1 Design** |  | 207d | 2006-05-08 | 2007-02-20 | 4 | 0d |  | RAL Technology | 1656h |
| 7 | 4.1 | Evaluate & Select technology |  | 1w | 2006-05-08 | 2006-05-12 |  | 0d |  |  |  |
| 8 | 4.2 | Analog sum + Comparator design study |  | 4w | 2006-05-15 | 2006-06-09 | 7 | 0d |  |  |  |
| 9 | 4.3 | **Schematic Design & Simulation** |  | 85d | 2006-06-12 | 2006-10-06 | 8 | 0d |  |  |  |
| 10 | 4.3.1 | Memory cell design & optomisation |  | 2w | 2006-06-12 | 2006-06-23 |  | 0d |  |  |  |
| 11 | 4.3.2 | Memory sense, readout +MUX design |  | 2w | 2006-06-26 | 2006-07-07 | 10 | 0d |  |  |  |
| 12 | 4.3.3 | Local Controller functional design |  | 2w | 2006-07-10 | 2006-07-21 | 11 | 0d |  |  |  |
| 13 | 4.3.4 | Graycode distribution |  | 2w | 2006-07-24 | 2006-08-04 | 12 | 0d |  |  |  |
| 14 | 4.3.5 | Pixel variants (4?) |  | 2w | 2006-08-07 | 2006-08-18 | 13 | 0d |  |  |  |
| 15 | 4.3.6 | Periphery circuits |  | 1w | 2006-08-21 | 2006-08-25 | 14 | 0d |  |  |  |
| 16 | 4.3.7 | Pad cells (inc Layouts) |  | 2w | 2006-08-28 | 2006-09-08 | 15 | 0d |  |  |  |
| 17 | 4.3.8 | Develop full ASIC1 schematics |  | 3w | 2006-09-11 | 2006-09-29 | 16 | 0d |  |  |  |
| 18 | 4.3.9 | Contingency |  | 1w | 2006-10-02 | 2006-10-06 | 17 | 0d |  |  |  |
| 19 | 4.4 | IDR - Schematic review | milestone | 1d | 2006-10-09 | 2006-10-09 | 9 | 0d |  |  |  |
| 20 | 4.5 | Holiday (Distributed throughout) |  | 4w | 2006-10-10 | 2006-11-06 | 19 | 0d |  |  |  |
| 21 | 4.6 | **Layout** |  | 55d | 2006-11-07 | 2007-01-22 | 20 | 0d |  |  |  |
| 22 | 4.6.1 | Base Pixel Layout |  | 1w | 2006-11-07 | 2006-11-13 |  | 0d |  |  |  |
| 23 | 4.6.2 | Pixel Variants |  | 1w | 2006-11-14 | 2006-11-20 | 22 | 0d |  |  |  |
| 24 | 4.6.3 | Local controller layout |  | 2w | 2006-11-21 | 2006-12-04 | 23 | 0d |  |  |  |
| 25 | 4.6.4 | Column base layout: Data mux |  | 2w | 2006-12-05 | 2006-12-18 | 24 | 0d |  |  |  |
| 26 | 4.6.5 | Biasing + Array power |  | 2w | 2006-12-19 | 2007-01-01 | 25 | 0d |  |  |  |
| 27 | 4.6.6 | Pad ring + Global connect |  | 2w | 2007-01-02 | 2007-01-15 | 26 | 0d |  |  |  |
| 28 | 4.6.7 | Congtingency |  | 1w | 2007-01-16 | 2007-01-22 | 27 | 0d |  |  |  |
| 29 | 4.7 | Top level DRC |  | 1w | 2007-01-23 | 2007-01-29 | 21 | 0d |  |  |  |
| 30 | 4.8 | Top level LVS |  | 1w | 2007-01-30 | 2007-02-05 | 29 | 0d |  |  |  |
| 31 | 4.9 | FDR - Layout & Pre-submission review | milestone | 1d | 2007-02-06 | 2007-02-06 | 30 | 0d |  |  |  |
| 32 | 4.10 | Follow up & Submission |  | 2w | 2007-02-07 | 2007-02-20 | 31 | 0d |  |  |  |
| 33 | 5 | Sienna Conference? TBC |  | 5d | 2006-10-02 | 2006-10-06 |  | 669d | start no earlier than 2006-10-02 |  |  |
| 34 | 6 | Fab-B shuttle Run? Date TBC | milestone | 1d | 2007-01-15 | 2007-01-15 |  | 598d | start no earlier than 2007-01-15 |  |  |
| 35 | 7 | Fab-B shuttle Run? Date TBC | milestone | 1d | 2007-02-26 | 2007-02-26 |  | 568d | start no earlier than 2007-02-26 |  |  |
| 36 | 8 | ASIC1 FDR | milestone | 1d? | 2007-02-21 | 2007-02-21 | 6 | 0d |  |  |  |
| 37 | 9 | ASIC1 Fab |  | 3mo | 2007-02-22 | 2007-05-16 | 36 | 0d |  | Silicon Foundry | 480h |

Notes:
- 33: Guilio will talk / Not sure if JC required?
- 34: 2006 date was 16th Jan / 2007 date not published yet
- 35: 2006 date was 27th Feb / 2007 date not published yet

| ID | WBS | Task | Duration | Start | Finish | Predecessors | Total slack | Free slack | Constraint | Resources | Work |
| --- | --- | --- | --- | --- | --- | --- | --- | --- | --- | --- | --- |
| 38 | 10 | **ASIC1 Test System** | 70d | 2007-02-22 | 2007-05-30 | 36 | 501d |  |  | Imperial College | 560h |
| 39 | 10.1 | PCB Design | 4w | 2007-02-22 | 2007-03-21 |  | 531d | 0d |  |  |  |
| 40 | 10.2 | PCB Manufacture & Assembly | 4w | 2007-03-22 | 2007-04-18 | 39 | 531d |  |  |  |  |
| 41 | 10.3 | FPGA Firmware development | 8w | 2007-02-22 | 2007-04-18 |  | 501d | 0d |  |  |  |
| 42 | 10.4 | Software development | 4w | 2007-04-19 | 2007-05-16 | 41 | 501d | 0d |  |  |  |
| 43 | 10.5 | Power-on / simple tests ahead of silicon | 2w | 2007-05-17 | 2007-05-30 | 42 | 501d |  |  |  |  |
| 44 | 11 | OptoDAQ Firmware changes | 1.5mo | 2007-02-22 | 2007-04-04 | 36 | 541d |  |  | IC? | 240h |
| 45 | 12 | ASIC1 Wire Bonding | 1w | 2007-05-17 | 2007-05-23 | 37 | 0d |  |  | RAL | 40h |
| 46 | 13 | ASIC1 basic tests | 2mo | 2007-05-24 | 2007-07-18 | 45 | 0d |  |  |  |  |
| 47 | 14 | ASIC1 detiled tests | 3mo | 2007-07-19 | 2007-10-10 | 46 | 406d |  |  |  |  |
| 48 | 15 | ASIC2 Spec review | 1w | 2007-07-19 | 2007-07-25 | 46 | 0d |  |  |  |  |
| 49 | 16 | ASIC2 Preliminary Design Review | 1d | 2007-07-26 | 2007-07-26 | 48 | 0d |  |  |  |  |
| 50 | 17 | ASIC2 Design | 7mo | 2007-07-27 | 2008-02-07 | 49 | 0d |  |  |  |  |
| 51 | 18 | ASIC2 Fab | 3mo | 2008-02-08 | 2008-05-01 | 50 | 0d |  |  |  |  |
| 52 | 19 | ASIC2 Sawing & Bonding | 1mo | 2008-05-02 | 2008-05-29 | 51 | 0d |  |  |  |  |
| 53 | 20 | ASIC2 basic tests | 2mo | 2008-05-30 | 2008-07-24 | 52 | 200d |  |  |  |  |
| 54 | 21 | ASIC2 detailed tests | 12mo | 2008-05-30 | 2009-04-30 | 52 | 0d |  |  |  |  |
| 55 | 22 | Beam test | 6mo | 2008-10-27 | 2009-04-10 |  | 14d |  | start no earlier than 2008-10-27 |  |  |
